# zec-plan-cms-2004_test

Schedule from MS Project, 2003-06-02 to 2005-02-21, A marks actual dates.
CERN

## Calendars

- Standard: Mon-Fri 08:00-12:00, 13:00-17:00; Sat-Sun off. Exceptions (off unless hours are given): 2003-10-30 to 2003-10-31, 2003-11-03, 2003-12-22 to 2003-12-26, 2003-12-29 to 2004-01-02.

## Schedule

| ID | WBS | Task | Type | Duration | Start | Finish | Complete | Remaining | Baseline start | Baseline finish | Baseline duration | Total slack | Constraint |
| --- | --- | --- | --- | --- | --- | --- | --- | --- | --- | --- | --- | --- | --- |
| 2 | 1 | **YB-2** |  | 268d | 2003-10-07 A | 2004-11-02 | 92% | 21.91d | 2003-10-07 | 2004-06-17 | 170d | 79d |  |
| 3 | 1.1 | Documentation / installation drawings finished | milestone | 0d | 2004-03-12 | 2004-03-12 |  |  | 2004-03-12 | 2004-03-12 | 0d | 216d | start no earlier than 2004-03-12 |
| 4 | 1.2 | Gas pipes installation |  | 154d | 2003-10-07 A | 2004-05-26 A | 100% |  | 2003-10-07 | 2004-05-03 | 137d |  | finish no earlier than 2004-05-26 |
| 5 | 1.3 | HO Nitrogen pipes installation |  | 9d | 2004-06-07 A | 2004-06-17 A | 100% |  | 2004-06-07 | 2004-06-17 | 9d |  | start no earlier than 2004-06-07 |
| 6 | 1.4 | Cooling pipes installation |  | 137d | 2003-10-07 A | 2004-05-03 A | 100% |  | 2003-10-07 | 2004-05-03 | 137d |  | finish no earlier than 2004-05-03 |
| 7 | 1.5 | Labeling cooling and gas |  | 12d | 2004-09-30 A | 2004-10-15 | 94% | 0.72d |  |  |  | 73d | finish no earlier than 2004-10-15 |
| 8 | 1.6 | Gas leak testing |  | 10d | 2004-09-30 | 2004-10-13 |  |  | 2004-05-03 | 2004-05-14 | 10d | 61.88d | start no earlier than 2004-09-30 |
| 9 | 1.7 | Gas loop test |  | 10d | 2004-09-30 | 2004-10-13 |  |  | 2004-05-03 | 2004-05-14 | 10d | 61.88d | start no earlier than 2004-09-30 |
| 10 | 1.8 | Cooling pressure testing |  | 7d | 2004-10-25 | 2004-11-02 |  |  | 2004-05-03 | 2004-05-11 | 7d | 61d | start no earlier than 2004-10-25 |
| 11 | 2 | **YB+2** |  | 243d | 2003-10-22 A | 2004-10-13 | 95% | 12.97d | 2003-10-22 | 2004-03-19 | 95d | 93d |  |
| 12 | 2.1 | Documentation / installation drawings finished | milestone | 0d | 2004-01-22 | 2004-01-22 |  |  | 2004-01-22 | 2004-01-22 | 0d | 251d | finish no earlier than 2004-01-22 |
| 13 | 2.2 | Gas pipes installation |  | 80d | 2003-10-22 A | 2004-02-27 A | 100% |  | 2003-10-22 | 2004-02-27 | 80d |  | finish no earlier than 2004-02-27 |
| 14 | 2.3 | HO Nitrogen Pipes installation |  | 83d | 2003-10-24 A | 2004-03-08 A | 100% |  | 2003-10-24 | 2004-03-08 | 83d |  | finish no earlier than 2004-03-08 |
| 15 | 2.4 | Cooling pipes installation |  | 86d | 2003-10-22 A | 2004-03-08 A | 100% |  | 2003-10-22 | 2004-03-08 | 86d |  | finish no earlier than 2004-03-08 |
| 16 | 2.5 | Labeling cooling and gas |  | 10d | 2004-08-04 A | 2004-08-18 A | 100% |  |  |  |  |  | finish no earlier than 2004-08-18 |
| 17 | 2.6 | Gas leak testing |  | 10d | 2004-09-30 | 2004-10-13 |  |  | 2004-03-08 | 2004-03-19 | 10d | 61.88d | start no earlier than 2004-09-30 |
| 18 | 2.7 | Gas loop test |  | 10d | 2004-09-30 A | 2004-10-13 | 50% | 5d | 2004-03-08 | 2004-03-19 | 10d | 61.88d | start no earlier than 2004-03-08 |
| 19 | 2.8 | Cooling pressure testing |  | 2d | 2004-06-14 A | 2004-06-15 A | 100% |  | 2004-03-08 | 2004-03-16 | 7d |  | start no earlier than 2004-06-14 |
| 20 | 3 | **YB+1** |  | 176d | 2004-02-25 A | 2004-10-27 | 91% | 15.26d | 2004-02-25 | 2004-06-18 | 83d | 83d | start no earlier than 2004-02-25 |
| 21 | 3.1 | Documentation / installation drawings finished | milestone | 0d | 2004-03-19 | 2004-03-19 |  |  | 2004-03-19 | 2004-03-19 | 0d | 211d | start no earlier than 2004-03-19 |
| 22 | 3.2 | Gas pipes installation |  | 42d | 2004-02-25 A | 2004-04-22 A | 100% |  | 2004-02-25 | 2004-04-22 | 42d |  | finish no earlier than 2004-04-22 |
| 23 | 3.3 | Nitrogen Pipes installation emergency |  | 10d | 2004-06-07 A | 2004-06-18 A | 100% |  | 2004-06-07 | 2004-06-18 | 10d |  | start no earlier than 2004-06-07 |
| 24 | 3.4 | HO Nitrogen pipes installation |  | 42d | 2004-02-25 A | 2004-04-22 A | 100% |  | 2004-02-25 | 2004-04-22 | 42d |  | start no earlier than 2004-02-25 |
| 25 | 3.5 | Cooling pipes installation |  | 42d | 2004-02-25 A | 2004-04-22 A | 100% |  | 2004-02-25 | 2004-04-22 | 42d |  | finish no earlier than 2004-04-22 |
| 26 | 3.6 | Labeling cooling and gas |  | 10d | 2004-09-03 A | 2004-09-17 A | 100% |  |  |  |  |  | finish no earlier than 2004-09-17 |
| 27 | 3.7 | Gas leak testing |  | 10d | 2004-10-14 | 2004-10-27 |  |  | 2004-05-05 | 2004-05-18 | 10d | 51.88d | start no earlier than 2004-10-14 |
| 28 | 3.8 | Gas loop test |  | 10d | 2004-10-14 A | 2004-10-27 | 50% | 5d | 2004-05-05 | 2004-05-18 | 10d | 51.88d | start no earlier than 2004-05-05 |
| 29 | 3.9 | Cooling pressure testing |  | 7d | 2004-09-13 A | 2004-09-21 A | 100% |  | 2004-04-23 | 2004-05-03 | 7d |  | start no earlier than 2004-09-13 |

Notes:
- 14: Missing flow meters

| ID | WBS | Task | Duration | Start | Finish | Predecessors | Complete | Remaining | Baseline start | Baseline finish | Baseline duration | Total slack | Free slack | Constraint |
| --- | --- | --- | --- | --- | --- | --- | --- | --- | --- | --- | --- | --- | --- | --- |
| 30 | 4 | **YB-1** | 110d | 2004-06-07 A | 2004-11-05 |  | 84% | 17.74d | 2004-05-21 | 2004-10-22 | 111d | 76d |  |  |
| 31 | 4.1 | Documentation cooling | 10d | 2004-08-24 A | 2004-09-06 |  | 80% | 2d | 2004-05-21 | 2004-05-21 | 0d | 88.88d |  | start no earlier than 2004-08-24 |
| 32 | 4.2 | Documentasjon Gas | 10d | 2004-09-06 A | 2004-09-17 |  | 80% | 2d |  |  |  | 79.88d |  | start no earlier than 2004-09-06 |
| 33 | 4.3 | Gas pipes installation RPC | 74d | 2004-06-18 A | 2004-09-30 A |  | 100% |  |  |  |  |  |  | finish no earlier than 2004-09-30 |
| 34 | 4.4 | Gas pipes installation DT | 84d | 2004-06-07 A | 2004-09-30 A |  | 100% |  | 2004-08-31 | 2004-10-11 | 30d |  |  | finish no earlier than 2004-09-30 |
| 35 | 4.5 | Nitrogen pipe installation Emergency | 5d | 2004-09-30 A | 2004-10-06 A |  | 100% |  |  |  |  |  |  | start no earlier than 2004-09-30 |
| 36 | 4.6 | HO Nitrogen pipe installation | 5d | 2004-10-21 | 2004-10-27 |  |  |  |  |  |  | 65d |  | start no earlier than 2004-10-21 |
| 37 | 4.7 | Cooling pipe installation | 90d | 2004-06-07 A | 2004-10-08 |  | 90% | 9d |  |  |  | 71d | 0d | finish no earlier than 2004-10-08 |
| 38 | 4.8 | Labeling cooling and gas | 5d | 2004-10-20 | 2004-10-27 |  |  |  |  |  |  | 65.12d |  | finish no earlier than 2004-10-27 |
| 39 | 4.9 | Gas Leak test | 10d | 2004-10-25 | 2004-11-05 |  |  |  |  |  |  | 44.88d |  | start no earlier than 2004-10-25 |
| 40 | 4.10 | Gas loop test | 10d | 2004-10-25 | 2004-11-05 |  |  |  | 2004-10-11 | 2004-10-22 | 10d | 44.88d |  | start no earlier than 2004-10-25 |
| 41 | 4.11 | Cooling leak/pressure testing | 7d | 2004-10-11 | 2004-10-19 | 37 |  |  | 2004-10-11 | 2004-10-19 | 7d | 71d |  |  |
| 42 | 5 | **YB0** | 138d | 2004-08-12 A | 2005-02-21 |  | 9% | 125.63d | 2004-04-01 | 2004-09-17 | 122d | 0d |  |  |
| 43 | 5.1 | Documentation for ECAL | 37d | 2004-08-12 A | 2004-10-01 A |  | 100% |  | 2004-04-01 | 2004-04-01 | 0d |  |  | finish no earlier than 2004-10-01 |
| 44 | 5.2 | Documentation for HCAL | 15d | 2004-10-01 | 2004-10-21 |  |  |  | 2004-04-01 | 2004-04-01 | 0d | 69d |  | start no earlier than 2004-10-01 |
| 45 | 5.3 | Documentation cooling, Muon and general | 12d | 2004-10-22 A | 2004-11-08 |  | 30% | 8.4d | 2004-04-01 | 2004-05-19 | 35d | 13d | 0d | start no earlier than 2004-10-22 |
| 46 | 5.4 | Documentation Gas DT and RPC | 12d | 2004-10-22 A | 2004-11-08 |  | 30% | 8.4d |  |  |  | 2d | 0d | start no earlier than 2004-10-22 |
| 47 | 5.5 | Documentation Nitrogen | 4d | 2004-11-02 | 2004-11-08 |  |  |  |  |  |  | 37.12d | 0d | finish no earlier than 2004-11-08 |
| 48 | 5.6 | ECAL cooling pipes (EB) installation | 66d | 2004-11-08 | 2005-02-07 |  |  |  | 2004-06-07 | 2004-09-06 | 66d | 10d |  | start no earlier than 2004-11-08 |
| 49 | 5.7 | ECAL insulation of cooling pipes | 55d | 2004-11-29 | 2005-02-11 |  |  |  | 2004-06-07 | 2004-09-06 | 66d | 6d |  | start no earlier than 2004-11-29 |
| 50 | 5.8 | HCAL cooling pipes (HB) installation | 66d | 2004-11-22 | 2005-02-21 |  |  |  | 2004-06-07 | 2004-09-06 | 66d | 0d |  | start no earlier than 2004-11-22 |
| 51 | 5.9 | Gas patch panels between feet | 15d | 2004-11-09 | 2004-11-29 | 46 |  |  | 2004-06-07 | 2004-09-06 | 66d | 42d |  | start no earlier than 2004-08-25 |
| 52 | 5.10 | RPC gas pipes installation | 45d | 2004-11-09 | 2005-01-10 | 46 |  |  | 2004-06-07 | 2004-09-06 | 66d | 2d | 0d | start no earlier than 2004-08-25 |
| 53 | 5.11 | DT Gas pipes installation | 45d | 2004-11-09 | 2005-01-10 | 46 |  |  | 2004-06-07 | 2004-09-06 | 66d | 2d | 0d | start no earlier than 2004-08-25 |
| 54 | 5.12 | Nitrogen Pipes installation emergency | 10d | 2004-11-08 | 2004-11-22 | 47 |  |  | 2004-06-07 | 2004-09-06 | 66d | 37.12d | 35.12d | start no earlier than 2004-08-25 |
| 55 | 5.13 | HO gas pipe installation | 10d | 2004-11-08 | 2004-11-22 | 47 |  |  | 2004-06-07 | 2004-09-06 | 66d | 37.12d | 35.12d | start no earlier than 2004-08-25 |
| 56 | 5.14 | Muon cooling pipe installation | 50d | 2004-11-09 | 2005-01-17 | 45 |  |  | 2004-06-07 | 2004-09-06 | 66d | 13d | 0d | start no earlier than 2004-08-25 |
| 57 | 5.15 | HO-RBX and LV , Yoke cooling pipe installation | 20d | 2004-11-09 | 2004-12-06 | 45 |  |  | 2004-06-07 | 2004-09-06 | 66d | 30d |  | start no earlier than 2004-08-25 |
| 58 | 5.16 | Labeling cooling and gas | 7d | 2004-12-13 | 2004-12-21 |  |  |  |  |  |  | 12.88d |  | start no earlier than 2004-12-13 |
| 59 | 5.17 | Gas leak testing | 7d | 2005-01-11 | 2005-01-19 | 52, 53, 54, 55 |  |  | 2004-09-06 | 2004-09-17 | 10d | 5d |  | start no earlier than 2004-12-01 |
| 60 | 5.18 | Gas loop test | 10d | 2005-01-11 | 2005-01-24 | 52, 53, 54, 55 |  |  | 2004-09-06 | 2004-09-17 | 10d | 2d |  | start no earlier than 2004-09-06 |
| 61 | 5.19 | Cooling leak/pressure testing | 7d | 2005-01-18 | 2005-01-26 | 56, 57 |  |  | 2004-09-06 | 2004-09-14 | 7d | 13d |  | start no earlier than 2004-09-06 |

Notes:
- 43: Needs 4 weeks for making documentation when information is received from CERN
- 44: Needs 4 weeks for making documentation when information is received from CERN
- 57: witek says 2 weeks

| ID | WBS | Task | Duration | Start | Finish | Predecessors | Complete | Remaining | Baseline start | Baseline finish | Baseline duration | Total slack | Free slack | Constraint |
| --- | --- | --- | --- | --- | --- | --- | --- | --- | --- | --- | --- | --- | --- | --- |
| 62 | 6 | **YE-1** | 227d? | 2004-04-02 A | 2005-02-14 |  | 48% | 118.2d? | 2004-04-02 | 2004-12-24 | 191d | 5d |  |  |
| 63 | 6.1 | Drawings RE1, RE2, ME1 | 32d | 2004-04-02 A | 2004-05-17 A |  | 100% |  | 2004-04-02 | 2004-04-02 | 0d |  |  | start no earlier than 2004-04-02 |
| 64 | 6.2 | Drawings EE manifold, Nitrogen | 21d | 2004-04-26 A | 2004-05-24 A |  | 100% |  |  |  |  |  |  | start no earlier than 2004-04-26 |
| 65 | 6.3 | Periphery Gas pipes installation RE1 (IT-3036) | 35d | 2004-06-07 A | 2004-07-23 A |  | 100% |  | 2004-04-22 | 2004-06-09 | 35d |  |  | start no earlier than 2004-06-07 |
| 66 | 6.4 | Periphery Gas pipes installation RE2 (IT-3036) | 35d | 2004-05-31 A | 2004-07-16 A |  | 100% |  | 2004-04-22 | 2004-06-09 | 35d |  |  | start no earlier than 2004-05-31 |
| 67 | 6.5 | Periphery Gas pipes installation ME1 (IT-3036) | 35d | 2004-04-22 A | 2004-06-09 A |  | 100% |  | 2004-04-22 | 2004-06-09 | 35d |  |  | start no earlier than 2004-04-22 |
| 68 | 6.6 | Periphery Nitrogen Pipes installation (IT-3036) | 10d | 2004-11-04 | 2004-11-17 |  |  |  | 2004-04-22 | 2004-06-09 | 35d | 40d | 0d | start no earlier than 2004-11-04 |
| 69 | 6.7 | Gas leak testing (IT-3036) | 10d | 2004-11-18 | 2004-12-01 | 65, 66, 67, 68 |  |  | 2004-06-09 | 2004-06-22 | 10d | 40d |  | start no earlier than 2004-06-09 |
| 70 | 6.8 | Gas loop test (IT-3036) | 10d | 2004-07-26 | 2004-08-06 | 65, 66, 67 |  |  | 2004-06-09 | 2004-06-22 | 10d | 109.88d |  | start no earlier than 2004-06-09 |
| 71 | 6.9 | Installation of ME manifold | 8d | 2004-06-08 A | 2004-06-17 A |  | 100% |  | 2004-06-01 | 2004-06-10 | 8d |  |  | start no earlier than 2004-06-08 |
| 72 | 6.10 | Installation radial cable trays | 15d | 2004-06-11 A | 2004-07-01 A |  | 100% |  | 2004-05-17 | 2004-05-28 | 10d |  |  | start no earlier than 2004-06-11 |
| 73 | 6.11 | Cooling pipe inst General cooling | 37d | 2004-07-09 A | 2004-08-31 A | 72 | 100% |  | 2004-06-21 | 2004-08-20 | 45d |  |  | finish no earlier than 2004-08-31 |
| 74 | 6.12 | connections ME manifold | 15d | 2004-09-08 | 2004-09-28 |  |  |  |  |  |  | 72.88d |  | start no earlier than 2004-09-08 |
| 75 | 6.13 | EE Cooling pipe inst radial part | 59d | 2004-08-09 A | 2004-10-28 | 72 | 60% | 23.6d | 2004-06-21 | 2004-08-20 | 45d | 77d |  | finish no earlier than 2004-10-28 |
| 76 | 6.14 | EE manifold (without x-mas trees) | 20d | 2004-11-08 | 2004-12-03 |  |  |  |  |  |  | 51d |  | start no earlier than 2004-11-08 |
| 77 | 6.15 | EE christmas tree, inst and connections | 10d? | 2004-11-24 | 2004-12-07 |  |  |  |  |  |  | 5d | 0d | start no earlier than 2004-11-24 |
| 78 | 6.16 | Chamber gas pipe inst ME1/1 | 18d | 2004-10-04 A | 2004-10-28 A | 72 | 100% |  | 2004-06-21 | 2004-08-20 | 45d |  |  | finish no earlier than 2004-10-28 |
| 79 | 6.17 | Chamber gas pipe inst RE 1/1 | 27d | 2004-09-21 | 2004-10-28 | 72 |  |  | 2004-06-21 | 2004-08-20 | 45d | 82.12d |  | finish no earlier than 2004-10-28 |
| 80 | 6.18 | ES gas (sniffer) | 20d | 2004-10-20 A | 2004-11-16 A |  | 100% |  |  |  |  |  |  | start no earlier than 2004-10-20 |
| 81 | 6.19 | EE sniffer | 7d | 2004-10-20 | 2004-10-28 |  |  |  |  |  |  | 77d |  | start no earlier than 2004-10-20 |
| 82 | 6.20 | ME1/1 sniffer | 14d | 2004-10-20 | 2004-11-08 |  |  |  |  |  |  | 70d |  | start no earlier than 2004-10-20 |
| 83 | 6.21 | PSD air | 14d | 2004-10-20 | 2004-11-08 |  |  |  |  |  |  | 70d |  | start no earlier than 2004-10-20 |
| 84 | 6.22 | EE N2 | 28d | 2004-09-20 | 2004-10-28 | 72 |  |  | 2004-06-21 | 2004-08-20 | 45d | 32.12d | 0d | finish no earlier than 2004-10-28 |
| 85 | 6.23 | RBX N2 | 20d | 2004-10-20 | 2004-11-16 |  |  |  |  |  |  | 64d |  | start no earlier than 2004-10-20 |
| 86 | 6.24 | Cooling pressure testing EE | 19d | 2004-12-08 | 2005-01-03 | 77 |  |  | 2004-08-23 | 2004-09-03 | 10d | 5d | 0d | finish no earlier than 2004-09-30 |
| 87 | 6.25 | Cooling pressure testing , General | 19d | 2004-09-29 | 2004-10-25 | 74 |  |  | 2004-08-23 | 2004-09-03 | 10d | 50d |  | finish no earlier than 2004-09-30 |
| 88 | 6.26 | Gas leak testing (ME1/1, RE1/1, RBX, EE, ES) | 10d | 2004-10-28 | 2004-11-11 | 84 |  |  | 2004-08-23 | 2004-09-03 | 10d | 67.12d |  | start no earlier than 2004-08-03 |
| 89 | 6.27 | Gas loop testing (ME1/1, RE1/1) | 10d | 2004-10-28 | 2004-11-11 | 84 |  |  | 2004-08-23 | 2004-09-03 | 10d | 67.12d |  | start no earlier than 2004-08-03 |
| 90 | 6.28 | ES installation of SS pipe, 3 & 9 o'clock | 10d | 2004-10-28 | 2004-11-11 | 84 |  |  | 2004-08-23 | 2004-09-03 | 10d | 27.12d | 0d | start no earlier than 2004-08-16 |
| 91 | 6.29 | ES insulation and wrapping, 3 & 9 o'clock | 10d | 2004-11-11 | 2004-11-25 | 90 |  |  | 2004-09-06 | 2004-09-17 | 10d | 27.12d |  | start no earlier than 2004-07-05 |
| 92 | 6.30 | ME1/1 chamber installation | 30d | 2005-01-04 | 2005-02-14 | 91, 86, 87 |  |  | 2004-08-23 | 2004-10-01 | 30d | 5d |  | start no earlier than 2004-08-23 |

Notes:
- 62: The gas and cooling installation for the YE1 end caps will have a separate team working on just this contract
- 63: 5 fitters team
- 65: missing drawings
- 66: zec problem with understanding layout of rack
- 67: connect pipes to rack missing
- 68: missing documentasjon

| ID | WBS | Task | Duration | Start | Finish | Predecessors | Complete | Remaining | Baseline start | Baseline finish | Baseline duration | Total slack | Free slack | Constraint |
| --- | --- | --- | --- | --- | --- | --- | --- | --- | --- | --- | --- | --- | --- | --- |
| 93 | 7 | **YE+1** | 174.88d? | 2004-05-24 A | 2005-01-21 |  | 52% | 84.7d? | 2004-04-23 | 2005-01-31 | 202d | 21.12d |  |  |
| 94 | 7.1 | Drawings RE1, RE2, ME1 | 10d | 2004-05-24 A | 2004-06-07 A |  | 100% |  | 2004-04-02 | 2004-04-02 | 0d |  |  | finish no earlier than 2004-06-07 |
| 95 | 7.2 | Drawings EE manifold, Nitrogen | 15d | 2004-05-24 A | 2004-06-11 |  | 80% | 3d |  |  |  | 176d |  | start no earlier than 2004-05-24 |
| 96 | 7.3 | Periphery Gas pipes installation RE1 (IT-3036) | 30d | 2004-07-20 A | 2004-08-30 A |  | 100% |  | 2004-05-04 | 2004-06-14 | 30d |  |  | start no earlier than 2004-07-20 |
| 97 | 7.4 | Periphery Gas pipes installation RE2 (IT-3036) | 30d | 2004-07-20 A | 2004-08-30 A |  | 100% |  | 2004-05-04 | 2004-06-14 | 30d |  |  | start no earlier than 2004-07-20 |
| 98 | 7.5 | Periphery Gas pipes installation ME1 (IT-3036) | 30d | 2004-07-20 A | 2004-08-30 A |  | 100% |  | 2004-05-04 | 2004-06-14 | 30d |  |  | start no earlier than 2004-07-20 |
| 99 | 7.6 | Periphery Nitrogen Pipes installation (IT-3036) | 59d | 2004-07-20 A | 2004-10-08 |  | 90% | 6.01d | 2004-05-04 | 2004-06-14 | 30d | 81d | 0d | finish no earlier than 2004-10-08 |
| 100 | 7.7 | Gas leak testing (IT-3036) | 10d | 2004-10-11 | 2004-10-22 | 96, 97, 99 |  |  | 2004-06-14 | 2004-06-25 | 10d | 81d |  | start no earlier than 2004-06-14 |
| 101 | 7.8 | Gas loop test (IT-3036) | 10d | 2004-08-31 | 2004-09-13 | 96, 97, 98 |  |  | 2004-06-14 | 2004-06-25 | 10d | 110d |  | start no earlier than 2004-06-14 |
| 102 | 7.9 | Installation of ME manifold | 8d | 2004-06-18 A | 2004-06-29 A |  | 100% |  | 2004-06-11 | 2004-06-22 | 8d |  |  | start no earlier than 2004-06-18 |
| 103 | 7.10 | connections ME manifold | 10d | 2004-09-21 | 2004-10-04 |  |  |  |  |  |  | 85d | 0d | start no earlier than 2004-09-21 |
| 104 | 7.11 | Installation radial cable trays | 10d | 2004-06-21 A | 2004-07-02 A |  | 100% |  | 2004-05-28 | 2004-06-10 | 10d |  |  | start no earlier than 2004-06-21 |
| 105 | 7.12 | Cooling pipe inst General cooling | 37d | 2004-09-20 A | 2004-11-09 A | 104 | 100% |  | 2004-08-23 | 2004-10-20 | 43d |  |  | start no earlier than 2004-09-20 |
| 106 | 7.13 | EE Cooling pipe inst radial part | 20d | 2004-10-20 A | 2004-11-16 | 104 | 55% | 9d | 2004-08-23 | 2004-10-20 | 43d | 64d |  | start no earlier than 2004-10-20 |
| 107 | 7.14 | EE manifold (without x-mas trees) | 20d | 2004-10-20 | 2004-11-16 |  |  |  |  |  |  | 64d |  | start no earlier than 2004-10-20 |
| 108 | 7.15 | connections EE christmas tree | 15d? | 2004-10-18 | 2004-11-05 |  |  |  |  |  |  | 61d | 0d | start no earlier than 2004-10-18 |
| 109 | 7.16 | Chamber gas pipe inst ME1/1 | 7d | 2004-11-01 A | 2004-11-09 A | 104 | 100% |  | 2004-08-23 | 2004-10-20 | 43d |  |  | start no earlier than 2004-11-01 |
| 110 | 7.17 | Chamber gas pipe inst RE 1/1 | 10d | 2004-11-01 | 2004-11-12 | 104 |  |  | 2004-08-23 | 2004-10-20 | 43d | 66d |  | start no earlier than 2004-11-01 |
| 111 | 7.18 | ES gas (sniffer) | 20d | 2004-10-20 A | 2004-11-16 A |  | 100% |  |  |  |  |  |  | start no earlier than 2004-10-20 |
| 112 | 7.19 | EE sniffer | 7d | 2004-10-20 | 2004-10-28 |  |  |  |  |  |  | 77d |  | start no earlier than 2004-10-20 |
| 113 | 7.20 | ME1/1 sniffer | 14d | 2004-10-20 | 2004-11-08 |  |  |  |  |  |  | 70d |  | start no earlier than 2004-10-20 |
| 114 | 7.21 | PSD air | 14d | 2004-10-20 | 2004-11-08 |  |  |  |  |  |  | 70d |  | start no earlier than 2004-10-20 |
| 115 | 7.22 | EE N2 | 7d | 2004-11-03 A | 2004-11-12 | 104 | 20% | 5.6d | 2004-08-23 | 2004-10-20 | 43d | 16.12d | 0d | finish no earlier than 2004-11-12 |
| 116 | 7.23 | RBX N2 | 20d | 2004-10-20 | 2004-11-16 |  |  |  |  |  |  | 64d |  | start no earlier than 2004-10-20 |
| 117 | 7.24 | Cooling pressure testing , EE | 10d | 2004-11-08 | 2004-11-19 | 108 |  |  | 2004-10-21 | 2004-11-03 | 10d | 61d |  | start no earlier than 2004-09-15 |
| 118 | 7.25 | Cooling pressure testing , General | 10d | 2004-10-05 | 2004-10-18 | 103 |  |  | 2004-10-21 | 2004-11-03 | 10d | 85d |  | start no earlier than 2004-09-15 |
| 119 | 7.26 | Gas leak testing (ME1/1, RE1/1, RBX, EE, ES) | 10d | 2004-11-12 | 2004-11-26 | 115 |  |  | 2004-10-21 | 2004-11-03 | 10d | 56.12d |  | start no earlier than 2004-09-15 |
| 120 | 7.27 | Gas loop testing (ME1/1, RE1/1) | 10d | 2004-11-12 | 2004-11-26 | 115 |  |  | 2004-10-21 | 2004-11-03 | 10d | 56.12d |  | start no earlier than 2004-09-15 |
| 121 | 7.28 | ES installation of SS pipe, 3 & 9 o'clock | 10d | 2004-11-12 | 2004-11-26 | 115 |  |  | 2004-09-28 | 2004-10-11 | 10d | 16.12d | 0d | start no earlier than 2004-09-28 |
| 122 | 7.29 | ES insulation and wrapping, 3 & 9 clock | 10d | 2004-11-26 | 2004-12-10 | 121 |  |  | 2004-10-12 | 2004-10-25 | 10d | 16.12d | 0d | start no earlier than 2004-07-05 |
| 123 | 7.30 | ME1/1 chamber installation | 30d | 2004-12-10 | 2005-01-21 | 122 |  |  | 2004-09-28 | 2004-11-08 | 30d | 16.12d |  | start no earlier than 2004-10-21 |

Notes:
- 93: Patch panels have to be installed before pipe installation begin.
- 94: 5 fitters team

| ID | WBS | Task | Type | Duration | Start | Finish | Complete | Remaining | Baseline start | Baseline finish | Baseline duration | Total slack | Constraint |
| --- | --- | --- | --- | --- | --- | --- | --- | --- | --- | --- | --- | --- | --- |
| 124 | 8 | **YE-3** |  | 366d | 2003-06-02 A | 2004-11-11 | 47% | 192.94d | 2003-06-02 | 2004-11-11 | 366d | 72d |  |
| 125 | 8.1 | Documentation / installation drawings finished | milestone | 0d | 2004-06-28 | 2004-06-28 |  |  | 2004-06-28 | 2004-06-28 | 0d | 166d | start no earlier than 2004-06-28 |
| 126 | 8.2 | Gas pipes installation CSC |  | 123d | 2003-06-02 A | 2003-11-24 A | 100% |  | 2003-06-02 | 2003-11-24 | 123d |  | start no earlier than 2003-06-02 |
| 127 | 8.3 | Gas pipe installation RPC |  | 15d | 2004-10-11 | 2004-10-29 |  |  | 2004-10-11 | 2004-10-29 | 15d | 76d | start no earlier than 2004-10-11 |
| 128 | 8.4 | Nitrogen Pipes installation |  | 342d | 2003-06-02 A | 2004-10-11 | 10% | 306.6d | 2003-06-02 | 2004-10-11 | 342d | 90.12d | finish no earlier than 2004-10-11 |
| 129 | 8.5 | Gas leak testing |  | 10d | 2004-10-29 | 2004-11-11 |  |  | 2004-10-29 | 2004-11-11 | 10d | 67d | start no earlier than 2004-10-29 |
| 130 | 8.6 | Gas loop test |  | 10d | 2003-11-14 A | 2003-11-27 | 50% | 5d | 2003-11-14 | 2003-11-27 | 10d | 307d | start no earlier than 2003-06-02 |
| 131 | 8.7 | **YE+3** |  | 356d | 2003-06-16 A | 2004-11-11 | 51% | 174.7d | 2003-06-16 | 2004-11-11 | 356d | 72d |  |
| 132 | 8.7.1 | Documentation / installation drawings finished | milestone | 0d | 2004-05-14 | 2004-05-14 |  |  | 2004-05-14 | 2004-05-14 | 0d | 197d | start no earlier than 2004-05-14 |
| 133 | 8.7.2 | Gas pipes installation CSC |  | 108d | 2003-06-16 A | 2003-11-17 A | 100% |  | 2003-06-16 | 2003-11-17 | 108d |  | start no earlier than 2003-06-16 |
| 134 | 8.7.3 | Gas pipe installation RPC |  | 15d | 2004-10-11 | 2004-10-29 |  |  | 2004-10-11 | 2004-10-29 | 15d | 76d | start no earlier than 2004-10-11 |
| 135 | 8.7.4 | Nitrogen Pipes installation |  | 132d | 2003-06-16 A | 2003-12-19 A | 100% |  | 2003-06-16 | 2003-12-19 | 132d |  | finish no earlier than 2003-12-19 |
| 136 | 8.7.5 | Gas leak testing |  | 225d | 2003-12-19 A | 2004-11-11 | 3% | 218d | 2003-12-19 | 2004-11-11 | 225d | 67d | finish no earlier than 2004-11-11 |
| 137 | 8.7.6 | Gas loop test |  | 5d | 2004-10-29 | 2004-11-04 |  |  | 2004-10-29 | 2004-11-04 | 5d | 72d | start no earlier than 2004-10-29 |
| 138 | 8.8 | **SX5 additional gas installation** |  | 95d | 2003-08-06 A | 2003-12-19 A | 100% |  | 2003-08-06 | 2003-12-19 | 95d |  |  |
| 139 | 8.8.1 | Gas pipe installation |  | 91d | 2003-08-06 A | 2003-12-15 A | 100% |  | 2003-08-06 | 2003-12-15 | 91d |  | finish no earlier than 2003-12-15 |
| 140 | 8.8.2 | Gas leak testing |  | 14d | 2003-12-02 A | 2003-12-19 A | 100% |  | 2003-12-02 | 2003-12-19 | 14d |  | finish no earlier than 2003-12-15 |
| 141 | 9 | **YE+2** |  | 306d | 2003-09-01 A | 2004-11-18 | 81% | 57.99d | 2003-09-01 | 2003-09-12 | 10d | 67d |  |
| 142 | 9.1 | Gas pipes installation |  | 12d | 2003-09-01 A | 2003-09-12 A | 100% |  | 2003-09-01 | 2003-09-12 | 12d |  | start no earlier than 2003-09-01 |
| 143 | 9.2 | Nitrogen Pipes installation |  | 12d | 2003-09-01 A | 2003-09-12 A | 100% |  | 2003-09-01 | 2003-09-12 | 12d |  | start no earlier than 2003-09-01 |
| 144 | 9.3 | Gas leak testing |  | 19d | 2004-10-25 A | 2004-11-18 | 69% | 5.88d | 2003-09-01 | 2003-09-12 | 10d | 62d | start no earlier than 2003-09-01 |
| 145 | 9.4 | Gas loop test |  | 19d | 2004-10-25 A | 2004-11-18 | 69% | 5.88d | 2003-09-01 | 2003-09-12 | 10d | 62d | start no earlier than 2003-09-01 |
| 146 | 10 | **YE-2** |  | 283d | 2003-10-15 A | 2004-12-01 | 75% | 70.75d | 2003-10-15 | 2003-10-28 | 10d | 58d |  |
| 147 | 10.1 | Gas pipes installation |  | 10d | 2003-10-15 A | 2003-10-28 A | 100% |  | 2003-10-15 | 2003-10-28 | 10d |  | start no earlier than 2003-10-15 |
| 148 | 10.2 | Nitrogen Pipes installation |  | 10d | 2003-10-15 A | 2003-10-28 A | 100% |  | 2003-10-15 | 2003-10-28 | 10d |  | start no earlier than 2003-10-15 |
| 149 | 10.3 | Gas leak testing |  | 10d | 2004-11-18 A | 2004-12-01 | 50% | 5d | 2003-10-15 | 2003-10-28 | 10d | 53d | start no earlier than 2003-10-15 |
| 150 | 10.4 | Gas loop test |  | 10d | 2004-11-18 A | 2004-12-01 | 50% | 5d | 2003-10-15 | 2003-10-28 | 10d | 53d | start no earlier than 2003-10-15 |

Notes:
- 127: 4 workers
- 128: about 1 week of work to finish with 4 workers
- 134: about 6 workers to do this installation
